# Proyecto de las oficinas centrales

How a schedule from MS Project changed from version to version. A marks actual dates.

## Version 1 (saved 2014-03-21, file GP-p4inicio.mpp)

| ID | WBS | Task | Duration | Start | Finish | Predecessors | Total float |
| --- | --- | --- | --- | --- | --- | --- | --- |
| 1 | 1 | **Reubicación oficinas centrales** | 82.38d | 2015-03-09 | 2015-07-01 |  | 0d |
| 2 | 1.1 | **Planificación** | 35d | 2015-03-09 | 2015-04-24 |  | 0.75d |
| 3 |  | Escribir propuesta | 3d | 2015-03-09 | 2015-03-11 |  | 0.75d |
| 4 |  | Contratar arquitecto | 2d | 2015-03-10 | 2015-03-11 | 3FF | 0.75d |
| 5 |  | Localizar nueva ubicación | 1w | 2015-03-12 | 2015-03-18 | 4 | 0.75d |
| 6 |  | Presentar propuesta | 2d | 2015-03-19 | 2015-03-20 | 5 | 0.75d |
| 7 |  | Aprobación de la directiva | 0d | 2015-03-20 | 2015-03-20 | 6 | 0.75d |
| 8 |  | Negociar nuevo alquiler | 4d | 2015-03-23 | 2015-03-26 | 7 | 0.75d |
| 9 |  | Terminar dibujos | 2w | 2015-03-25 | 2015-04-07 | 8FS-2d | 0.75d |
| 10 |  | Seleccionar subcontratados | 1.5w | 2015-04-06 | 2015-04-15 | 9FS-2d | 0.75d |
| 11 |  | Contratar empresa de mudanzas | 3d | 2015-04-10 | 2015-04-15 | 10FF | 0.75d |
| 12 |  | Enviar dibujos | 1.5w | 2015-04-15 | 2015-04-24 | 11 | 0.75d |
| 13 |  | Permisos recibidos | 0d | 2015-04-24 | 2015-04-24 | 12 | 0.75d |
| 14 | 1.2 | **Remodelación** | 38d | 2015-04-27 | 2015-06-17 | 2 | 0d |
| 15 |  | Demolición del espacio existente | 3d | 2015-04-27 | 2015-04-29 |  | 0.75d |
| 16 |  | Levantar tabiques | 4d | 2015-04-30 | 2015-05-05 | 15 | 0.75d |
| 17 |  | Instalación eléctrica | 6d | 2015-05-06 | 2015-05-13 | 16 | 0.75d |
| 18 |  | Instalación de líneas de voz y datos | 3d | 2015-05-07 | 2015-05-11 | 17SS+1d | 2.75d |
| 19 |  | Terminar paredes | 2w | 2015-05-14 | 2015-05-27 | 17, 18 | 0.75d |
| 20 |  | Instalar puertas y ventanas | 3d | 2015-05-26 | 2015-05-28 | 19FS-2d | 4.75d |
| 21 |  | Pintar | 4d | 2015-05-26 | 2015-05-29 | 19FS-2d | 0.75d |
| 22 |  | Colocar moqueta: oficinas | 3d | 2015-06-01 | 2015-06-03 | 21 | 0.75d |
| 23 |  | Colocar linóleo: sala del servidor | 3d | 2015-06-01 | 2015-06-03 | 22SS | 0.75d |
| 24 |  | Ultimas reparaciones | 1w | 2015-06-04 | 2015-06-10 | 20, 22, 23 | 0.75d |
| 25 |  | Probar sistemas | 2d | 2015-06-11 | 2015-06-12 | 24 | 1.75d |
| 26 |  | Revisión de acabado | 3d | 2015-06-11 | 2015-06-15 | 24, 25FF | 0.75d |
| 27 |  | Limpieza final | 2d | 2015-06-15 | 2015-06-17 | 26 | 0d |
| 28 |  | Remodelación terminada | 0d | 2015-06-17 | 2015-06-17 | 27 | 0d |
| 29 | 1.3 | **Traslado** | 9.38d | 2015-06-18 | 2015-07-01 | 14 | 0d |
| 30 | 1.3.1 | **Oficinas** | 6.5d | 2015-06-18 | 2015-06-26 |  | 0d |
| 31 |  | Desconectar computadoras/equipos | 2d | 2015-06-18 | 2015-06-19 |  | 0d |
| 32 |  | Desmontar mobiliario | 2d | 2015-06-19 | 2015-06-22 | 31FS-1d | 2.88d |
| 33 |  | Trasladar mobiliario/equipo/cajas | 4h | 2015-06-23 | 2015-06-23 | 32 | 2.88d |
| 34 |  | Montar mobiliario | 2d | 2015-06-23 | 2015-06-25 | 33 | 2.88d |
| 35 |  | Conectar computadoras/equipos | 2d | 2015-06-24 | 2015-06-26 | 34FS-1d | 2.88d |
| 36 |  | Oficinas terminadas | 0d | 2015-06-26 | 2015-06-26 | 35 | 2.88d |
| 37 | 1.3.2 | **Sala del servidor** | 7.38d | 2015-06-22 | 2015-07-01 | 31 | 0d |
| 38 |  | Hacer copia de seguridad del servidor | 15h | 2015-06-22 | 2015-06-23 |  | 0d |
| 39 |  | Desconectar servidor | 2d | 2015-06-23 | 2015-06-25 | 38 | 0d |
| 40 |  | Trasladar servidor | 4h | 2015-06-25 | 2015-06-26 | 39 | 0d |
| 41 |  | Conectar servidor | 2d | 2015-06-26 | 2015-06-30 | 40 | 0d |
| 42 |  | Probar servidor | 1d | 2015-06-30 | 2015-07-01 | 41 | 0d |
| 43 |  | Sala del servidor terminada | 0d | 2015-07-01 | 2015-07-01 | 42 | 0d |
| 44 |  | Traslado terminado | 0d | 2015-07-01 | 2015-07-01 | 29, 36 | 0d |

## Version 2 (saved 2014-03-21, file GP-p4solucion.mpp)

Last finish 2015-07-01 → 2015-11-05 (+127d).

Changed:

| ID | Task | Start | Finish | Duration | Total float | Other |
| --- | --- | --- | --- | --- | --- | --- |
| 1 | **Reubicación oficinas centrales** | 2015-03-09 → 2015-07-28 (+141d) | 2015-07-01 → 2015-11-05 (+127d) | 82.38d → 71.62d |  | constraint none → as late as possible |
| 2 | **Planificación** | 2015-03-09 → 2015-07-28 (+141d) | 2015-04-24 → 2015-09-08 (+137d) | 35d → 30d | 0.75d → 0d | constraint none → as late as possible |
| 3 | Escribir propuesta | 2015-03-09 → 2015-07-28 (+141d) | 2015-03-11 → 2015-07-31 (+142d) |  | 0.75d → 0d |  |
| 4 | Contratar arquitecto | 2015-03-10 → 2015-07-29 (+141d) | 2015-03-11 → 2015-07-31 (+142d) |  | 0.75d → 0d |  |
| 5 | Localizar nueva ubicación | 2015-03-12 → 2015-07-31 (+141d) | 2015-03-18 → 2015-08-07 (+142d) |  | 0.75d → 0d |  |
| 6 | Presentar propuesta | 2015-03-19 → 2015-08-07 (+141d) | 2015-03-20 → 2015-08-11 (+144d) |  | 0.75d → 0d |  |
| 7 | Aprobación de la directiva | 2015-03-20 → 2015-08-11 (+144d) | 2015-03-20 → 2015-08-11 (+144d) |  | 0.75d → 0d |  |
| 8 | Negociar nuevo alquiler | 2015-03-23 → 2015-08-11 (+141d) | 2015-03-26 → 2015-08-17 (+144d) |  | 0.75d → 0d |  |
| 9 | Terminar dibujos | 2015-03-25 → 2015-08-13 (+141d) | 2015-04-07 → 2015-08-20 (+135d) | 2w → 1w | 0.75d → 0d | resources arquitecto → arquitecto [200%] |
| 10 | Seleccionar subcontratados | 2015-04-06 → 2015-08-18 (+134d) | 2015-04-15 → 2015-08-28 (+135d) |  | 0.75d → 0d |  |
| 11 | Contratar empresa de mudanzas | 2015-04-10 → 2015-08-25 (+137d) | 2015-04-15 → 2015-08-28 (+135d) |  | 0.75d → 0d |  |
| 12 | Enviar dibujos | 2015-04-15 → 2015-08-28 (+135d) | 2015-04-24 → 2015-09-08 (+137d) |  | 0.75d → 0d |  |
| 13 | Permisos recibidos | 2015-04-24 → 2015-09-08 (+137d) | 2015-04-24 → 2015-09-08 (+137d) |  | 0.75d → 0d |  |
| 14 | **Remodelación** | 2015-04-27 → 2015-09-08 (+134d) | 2015-06-17 → 2015-10-22 (+127d) | 38d → 32.25d |  | constraint none → as late as possible |
| 15 | Demolición del espacio existente | 2015-04-27 → 2015-09-08 (+134d) | 2015-04-29 → 2015-09-11 (+135d) |  | 0.75d → 0d |  |
| 16 | Levantar tabiques | 2015-04-30 → 2015-09-11 (+134d) | 2015-05-05 → 2015-09-17 (+135d) |  | 0.75d → 0d |  |
| 17 | Instalación eléctrica | 2015-05-06 → 2015-09-17 (+134d) | 2015-05-13 → 2015-09-25 (+135d) |  | 0.75d → 0d |  |
| 18 | Instalación de líneas de voz y datos | 2015-05-07 → 2015-09-18 (+134d) | 2015-05-11 → 2015-09-23 (+135d) |  | 2.75d → 2d |  |
| 19 | Terminar paredes | 2015-05-14 → 2015-09-25 (+134d) | 2015-05-27 → 2015-10-02 (+128d) | 2w → 1w | 0.75d → 0d | resources pintor → pintor; empresa constructora |
| 20 | Instalar puertas y ventanas | 2015-05-26 → 2015-09-30 (+127d) | 2015-05-28 → 2015-10-05 (+130d) |  | 4.75d → 4d |  |
| 21 | Pintar | 2015-05-26 → 2015-09-30 (+127d) | 2015-05-29 → 2015-10-06 (+130d) |  | 0.75d → 0d |  |
| 22 | Colocar moqueta: oficinas | 2015-06-01 → 2015-10-06 (+127d) | 2015-06-03 → 2015-10-09 (+128d) |  | 0.75d → 0d |  |
| 23 | Colocar linóleo: sala del servidor | 2015-06-01 → 2015-10-06 (+127d) | 2015-06-03 → 2015-10-09 (+128d) |  | 0.75d → 0d |  |
| 24 | Ultimas reparaciones | 2015-06-04 → 2015-10-09 (+127d) | 2015-06-10 → 2015-10-16 (+128d) |  | 0.75d → 0d | resources carpintero → carpintero; electricista |
| 25 | Probar sistemas | 2015-06-11 → 2015-10-16 (+127d) | 2015-06-12 → 2015-10-20 (+130d) |  | 1.75d → 1d |  |
| 26 | Revisión de acabado | 2015-06-11 → 2015-10-16 (+127d) | 2015-06-15 → 2015-10-21 (+128d) |  | 0.75d → 0d |  |
| 27 | Limpieza final | 2015-06-15 → 2015-10-21 (+128d) | 2015-06-17 → 2015-10-22 (+127d) |  |  |  |
| 28 | Remodelación terminada | 2015-06-17 → 2015-10-22 (+127d) | 2015-06-17 → 2015-10-22 (+127d) |  | 0d → 0.62d |  |
| 29 | **Traslado** | 2015-06-18 → 2015-10-23 (+127d) | 2015-07-01 → 2015-11-05 (+127d) |  |  | constraint none → as late as possible |
| 30 | **Oficinas** | 2015-06-18 → 2015-10-23 (+127d) | 2015-06-26 → 2015-11-02 (+129d) |  |  | constraint none → as late as possible |
| 31 | Desconectar computadoras/equipos | 2015-06-18 → 2015-10-23 (+127d) | 2015-06-19 → 2015-10-26 (+129d) |  | 0d → 0.62d |  |
| 32 | Desmontar mobiliario | 2015-06-19 → 2015-10-26 (+129d) | 2015-06-22 → 2015-10-27 (+127d) |  | 2.88d → 3.5d |  |
| 33 | Trasladar mobiliario/equipo/cajas | 2015-06-23 → 2015-10-28 (+127d) | 2015-06-23 → 2015-10-28 (+127d) |  | 2.88d → 3.5d |  |
| 34 | Montar mobiliario | 2015-06-23 → 2015-10-28 (+127d) | 2015-06-25 → 2015-10-30 (+127d) |  | 2.88d → 3.5d |  |
| 35 | Conectar computadoras/equipos | 2015-06-24 → 2015-10-29 (+127d) | 2015-06-26 → 2015-11-02 (+129d) |  | 2.88d → 3.5d |  |
| 36 | Oficinas terminadas | 2015-06-26 → 2015-11-02 (+129d) | 2015-06-26 → 2015-11-02 (+129d) |  | 2.88d → 3.5d |  |
| 37 | **Sala del servidor** | 2015-06-22 → 2015-10-27 (+127d) | 2015-07-01 → 2015-11-05 (+127d) |  |  | constraint none → as late as possible |
| 38 | Hacer copia de seguridad del servidor | 2015-06-22 → 2015-10-27 (+127d) | 2015-06-23 → 2015-10-28 (+127d) |  | 0d → 0.62d |  |
| 39 | Desconectar servidor | 2015-06-23 → 2015-10-28 (+127d) | 2015-06-25 → 2015-10-30 (+127d) |  | 0d → 0.62d |  |
| 40 | Trasladar servidor | 2015-06-25 → 2015-10-30 (+127d) | 2015-06-26 → 2015-11-02 (+129d) |  | 0d → 0.62d |  |
| 41 | Conectar servidor | 2015-06-26 → 2015-11-02 (+129d) | 2015-06-30 → 2015-11-04 (+127d) |  | 0d → 0.62d |  |
| 42 | Probar servidor | 2015-06-30 → 2015-11-04 (+127d) | 2015-07-01 → 2015-11-05 (+127d) |  | 0d → 0.62d |  |
| 43 | Sala del servidor terminada | 2015-07-01 → 2015-11-05 (+127d) | 2015-07-01 → 2015-11-05 (+127d) |  | 0d → 0.62d |  |
| 44 | Traslado terminado | 2015-07-01 → 2015-11-05 (+127d) | 2015-07-01 → 2015-11-05 (+127d) |  | 0d → 0.62d |  |

## Version 3 (saved 2014-03-24, file GP-p5delimitaciones.mpp)

Last finish 2015-11-05 → 2015-12-02 (+27d).

Changed:

| ID | Task | Start | Finish | Duration | Total float | Predecessors | Other |
| --- | --- | --- | --- | --- | --- | --- | --- |
| 1 | **Reubicación oficinas centrales** | 2015-07-28 → 2015-08-10 (+13d) | 2015-11-05 → 2015-12-02 (+27d) | 71.62d → 82.38d |  |  | constraint as late as possible → none |
| 2 | **Planificación** | 2015-07-28 → 2015-08-10 (+13d) | 2015-09-08 → 2015-09-24 (+16d) | 30d → 34d | 0d → 0.25d |  | constraint as late as possible → none |
| 3 | Escribir propuesta | 2015-07-28 → 2015-08-10 (+13d) | 2015-07-31 → 2015-08-12 (+12d) |  | 0d → 0.25d |  |  |
| 4 | Contratar arquitecto | 2015-07-29 → 2015-08-13 (+15d) | 2015-07-31 → 2015-08-14 (+14d) |  | 0d → 0.25d | 3FF → 3 |  |
| 5 | Localizar nueva ubicación | 2015-07-31 → 2015-08-17 (+17d) | 2015-08-07 → 2015-08-21 (+14d) |  | 0d → 0.25d |  |  |
| 6 | Presentar propuesta | 2015-08-07 → 2015-08-24 (+17d) | 2015-08-11 → 2015-08-25 (+14d) |  | 0d → 0.25d |  | resources jefe de operaciones; sala de conferencias; arquitecto → jefe de operaciones; sala de conferencias; arquitecto; presidente; vicepresidente |
| 7 | Aprobación de la directiva | 2015-08-11 → 2015-08-25 (+14d) | 2015-08-11 → 2015-08-25 (+14d) |  | 0d → 0.25d |  |  |
| 8 | Negociar nuevo alquiler | 2015-08-11 → 2015-08-26 (+15d) | 2015-08-17 → 2015-08-31 (+14d) |  | 0d → 0.25d |  |  |
| 9 | Terminar dibujos | 2015-08-13 → 2015-08-28 (+15d) | 2015-08-20 → 2015-09-03 (+14d) |  | 0d → 0.25d |  |  |
| 10 | Seleccionar subcontratados | 2015-08-18 → 2015-09-04 (+17d) | 2015-08-28 → 2015-09-15 (+18d) |  | 0d → 0.25d | 9FS-2d → 9 |  |
| 11 | Contratar empresa de mudanzas | 2015-08-25 → 2015-09-09 (+15d) | 2015-08-28 → 2015-09-15 (+18d) | 3d → 4d | 0d → 0.25d |  | resources jefe de operaciones [50%] → jefe de operaciones [75%] |
| 12 | Enviar dibujos | 2015-08-28 → 2015-09-15 (+18d) | 2015-09-08 → 2015-09-24 (+16d) |  | 0d → 0.25d |  | resources arquitecto → arquitecto; auxiliar administrativo [50%] |
| 13 | Permisos recibidos | 2015-09-08 → 2015-09-24 (+16d) | 2015-09-08 → 2015-09-24 (+16d) |  | 0d → 0.25d |  |  |
| 14 | **Remodelación** | 2015-09-08 → 2015-09-25 (+17d) | 2015-10-22 → 2015-11-18 (+27d) | 32.25d → 39d |  |  | constraint as late as possible → none |
| 15 | Demolición del espacio existente | 2015-09-08 → 2015-09-25 (+17d) | 2015-09-11 → 2015-09-29 (+18d) |  | 0d → 0.25d |  |  |
| 16 | Levantar tabiques | 2015-09-11 → 2015-09-30 (+19d) | 2015-09-17 → 2015-10-05 (+18d) | 4d → 3.5d | 0d → 0.25d |  | resources empresa constructora → empresa constructora [150%] |
| 17 | Instalación eléctrica | 2015-09-17 → 2015-10-05 (+18d) | 2015-09-25 → 2015-10-13 (+18d) |  | 0d → 0.25d |  |  |
| 18 | Instalación de líneas de voz y datos | 2015-09-18 → 2015-10-14 (+26d) | 2015-09-23 → 2015-10-19 (+26d) |  | 2d → 0.25d | 17SS+1d → 17FS+1d |  |
| 19 | Terminar paredes | 2015-09-25 → 2015-10-19 (+24d) | 2015-10-02 → 2015-10-26 (+24d) |  | 0d → 0.25d | 17, 18 → 18 |  |
| 20 | Instalar puertas y ventanas | 2015-09-30 → 2015-10-22 (+22d) | 2015-10-05 → 2015-10-27 (+22d) |  | 4d → 0.25d |  |  |
| 21 | Pintar | 2015-09-30 → 2015-10-27 (+27d) | 2015-10-06 → 2015-11-02 (+27d) |  | 0d → 0.25d | 19FS-2d → 20 |  |
| 22 | Colocar moqueta: oficinas | 2015-10-06 → 2015-11-02 (+27d) | 2015-10-09 → 2015-11-05 (+27d) |  | 0d → 0.25d |  |  |
| 23 | Colocar linóleo: sala del servidor | 2015-10-06 → 2015-11-02 (+27d) | 2015-10-09 → 2015-11-05 (+27d) |  | 0d → 0.25d |  |  |
| 24 | Ultimas reparaciones | 2015-10-09 → 2015-11-05 (+27d) | 2015-10-16 → 2015-11-12 (+27d) |  | 0d → 0.25d | 20, 22, 23 → 22, 23 | resources carpintero; electricista → carpintero [50%]; electricista [50%] |
| 25 | Probar sistemas | 2015-10-16 → 2015-11-12 (+27d) | 2015-10-20 → 2015-11-16 (+27d) |  | 1d → 1.25d |  |  |
| 26 | Revisión de acabado | 2015-10-16 → 2015-11-12 (+27d) | 2015-10-21 → 2015-11-17 (+27d) |  | 0d → 0.25d |  |  |
| 27 | Limpieza final | 2015-10-21 → 2015-11-17 (+27d) | 2015-10-22 → 2015-11-18 (+27d) |  |  |  |  |
| 28 | Remodelación terminada | 2015-10-22 → 2015-11-18 (+27d) | 2015-10-22 → 2015-11-18 (+27d) |  | 0.62d → 0d |  |  |
| 29 | **Traslado** | 2015-10-23 → 2015-11-19 (+27d) | 2015-11-05 → 2015-12-02 (+27d) |  |  |  | constraint as late as possible → none |
| 30 | **Oficinas** | 2015-10-23 → 2015-11-19 (+27d) | 2015-11-02 → 2015-11-26 (+24d) | 6.5d → 6d |  |  | constraint as late as possible → none |
| 31 | Desconectar computadoras/equipos | 2015-10-23 → 2015-11-19 (+27d) | 2015-10-26 → 2015-11-20 (+25d) |  | 0.62d → 0d |  |  |
| 32 | Desmontar mobiliario | 2015-10-26 → 2015-11-20 (+25d) | 2015-10-27 → 2015-11-23 (+27d) |  | 3.5d → 3.25d |  |  |
| 33 | Trasladar mobiliario/equipo/cajas | 2015-10-28 → 2015-11-24 (+27d) | 2015-10-28 → 2015-11-24 (+27d) |  | 3.5d → 3.25d |  | resources ordenanza → ordenanza; camión |
| 34 | Montar mobiliario | 2015-10-28 → 2015-11-24 (+27d) | 2015-10-30 → 2015-11-26 (+27d) |  | 3.5d → 3.25d |  |  |
| 35 | Conectar computadoras/equipos | 2015-10-29 → 2015-11-25 (+27d) | 2015-11-02 → 2015-11-26 (+24d) |  | 3.5d → 3d |  | resources técnico informático 1 [200%] → técnico informático 2 |
| 36 | Oficinas terminadas | 2015-11-02 → 2015-11-26 (+24d) | 2015-11-02 → 2015-11-26 (+24d) |  | 3.5d → 3.38d |  |  |
| 37 | **Sala del servidor** | 2015-10-27 → 2015-11-23 (+27d) | 2015-11-05 → 2015-12-02 (+27d) |  |  |  | constraint as late as possible → none |
| 38 | Hacer copia de seguridad del servidor | 2015-10-27 → 2015-11-23 (+27d) | 2015-10-28 → 2015-11-24 (+27d) |  | 0.62d → 0d |  |  |
| 39 | Desconectar servidor | 2015-10-28 → 2015-11-24 (+27d) | 2015-10-30 → 2015-11-26 (+27d) |  | 0.62d → 0d |  |  |
| 40 | Trasladar servidor | 2015-10-30 → 2015-11-26 (+27d) | 2015-11-02 → 2015-11-27 (+25d) |  | 0.62d → 0d |  | resources ordenanza → ordenanza; camión |
| 41 | Conectar servidor | 2015-11-02 → 2015-11-27 (+25d) | 2015-11-04 → 2015-12-01 (+27d) |  | 0.62d → 0d |  |  |
| 42 | Probar servidor | 2015-11-04 → 2015-12-01 (+27d) | 2015-11-05 → 2015-12-02 (+27d) |  | 0.62d → 0d |  |  |
| 43 | Sala del servidor terminada | 2015-11-05 → 2015-12-02 (+27d) | 2015-11-05 → 2015-12-02 (+27d) |  | 0.62d → 0d |  |  |
| 44 | Traslado terminado | 2015-11-05 → 2015-12-02 (+27d) | 2015-11-05 → 2015-12-02 (+27d) |  | 0.62d → 0d |  |  |

## Version 4 (saved 2014-03-24, file GP-p5delimitaciones_solucion.mpp)

Last finish stays 2015-12-02.

Changed:

| ID | Task | Total float | Other |
| --- | --- | --- | --- |
| 8 | Negociar nuevo alquiler | 0.25d → 0d | constraint none → finish no later than 2015-08-31 |
| 15 | Demolición del espacio existente |  | constraint none → start no earlier than 2015-09-21 |

## Version 5 (saved 2014-03-25, file GP-p6inicio.mpp)

Last finish 2015-12-02 → 2015-12-01 (-1d).

Changed:

| ID | Task | Start | Finish | Duration | Total float | Predecessors | Other |
| --- | --- | --- | --- | --- | --- | --- | --- |
| 1 | **Reubicación oficinas centrales** |  | 2015-12-02 → 2015-12-01 (-1d) | 82.38d → 81.12d |  |  |  |
| 8 | Negociar nuevo alquiler |  |  |  | 0d → 0.25d |  | constraint finish no later than 2015-08-31 → finish no later than 2015-09-01 |
| 29 | **Traslado** | 2015-11-19 → 2015-11-17 (-2d) | 2015-12-02 → 2015-12-01 (-1d) |  |  | 14 → 27SS |  |
| 30 | **Oficinas** | 2015-11-19 → 2015-11-17 (-2d) | 2015-11-26 → 2015-11-25 (-1d) | 6d → 6.25d |  |  |  |
| 31 | Desconectar computadoras/equipos | 2015-11-19 → 2015-11-17 (-2d) | 2015-11-20 → 2015-11-19 (-1d) |  |  |  |  |
| 32 | Desmontar mobiliario | 2015-11-20 → 2015-11-18 (-2d) | 2015-11-23 → 2015-11-20 (-3d) |  | 3.25d → 3.5d |  |  |
| 33 | Trasladar mobiliario/equipo/cajas | 2015-11-24 → 2015-11-20 (-4d) | 2015-11-24 → 2015-11-23 (-1d) |  | 3.25d → 3.5d |  |  |
| 34 | Montar mobiliario | 2015-11-24 → 2015-11-23 (-1d) | 2015-11-26 → 2015-11-25 (-1d) |  | 3.25d → 3.5d |  |  |
| 35 | Conectar computadoras/equipos | 2015-11-25 → 2015-11-24 (-1d) | 2015-11-26 → 2015-11-25 (-1d) |  |  |  |  |
| 36 | Oficinas terminadas | 2015-11-26 → 2015-11-25 (-1d) | 2015-11-26 → 2015-11-25 (-1d) |  | 3.38d → 3.12d |  |  |
| 37 | **Sala del servidor** | 2015-11-23 → 2015-11-19 (-4d) | 2015-12-02 → 2015-12-01 (-1d) |  |  |  |  |
| 38 | Hacer copia de seguridad del servidor | 2015-11-23 → 2015-11-19 (-4d) | 2015-11-24 → 2015-11-23 (-1d) |  |  |  |  |
| 39 | Desconectar servidor | 2015-11-24 → 2015-11-23 (-1d) | 2015-11-26 → 2015-11-25 (-1d) |  |  |  |  |
| 40 | Trasladar servidor | 2015-11-26 → 2015-11-25 (-1d) | 2015-11-27 → 2015-11-26 (-1d) |  |  |  |  |
| 41 | Conectar servidor | 2015-11-27 → 2015-11-26 (-1d) | 2015-12-01 → 2015-11-30 (-1d) |  |  |  |  |
| 42 | Probar servidor | 2015-12-01 → 2015-11-30 (-1d) | 2015-12-02 → 2015-12-01 (-1d) |  |  |  |  |
| 43 | Sala del servidor terminada | 2015-12-02 → 2015-12-01 (-1d) | 2015-12-02 → 2015-12-01 (-1d) |  |  |  |  |
| 44 | Traslado terminado | 2015-12-02 → 2015-12-01 (-1d) | 2015-12-02 → 2015-12-01 (-1d) |  |  |  |  |

## Version 6 (data date 2015-10-08, saved 2014-03-25, file GP-p6solucion.mpp)

Last finish 2015-12-01 → 2015-11-27 (-4d). Complete tasks 0 → 13.

Changed:

| ID | Task | Start | Finish | Duration | Complete | Total float | Other |
| --- | --- | --- | --- | --- | --- | --- | --- |
| 1 | **Reubicación oficinas centrales** | 2015-08-10 A | 2015-12-01 → 2015-11-27 (-4d) | 81.12d → 79.12d | 0% → 50% |  | baseline start none → 2015-08-10; baseline finish none → 2015-12-01 |
| 2 | **Planificación** | 2015-08-10 A | 2015-09-24 → 2015-09-22 A (-2d) | 34d → 32d | 0% → 100% | 0.25d → none | baseline start none → 2015-08-10; baseline finish none → 2015-09-24 |
| 3 | Escribir propuesta | 2015-08-10 A | 2015-08-12 → 2015-08-11 A (-1d) | 3d → 2d | 0% → 100% | 0.25d → none | baseline start none → 2015-08-10; baseline finish none → 2015-08-12 |
| 4 | Contratar arquitecto | 2015-08-13 → 2015-08-12 A (-1d) | 2015-08-14 → 2015-08-13 A (-1d) |  | 0% → 100% | 0.25d → none | baseline start none → 2015-08-13; baseline finish none → 2015-08-14 |
| 5 | Localizar nueva ubicación | 2015-08-17 → 2015-08-14 A (-3d) | 2015-08-21 → 2015-08-20 A (-1d) |  | 0% → 100% | 0.25d → none | baseline start none → 2015-08-17; baseline finish none → 2015-08-21 |
| 6 | Presentar propuesta | 2015-08-24 → 2015-08-21 A (-3d) | 2015-08-25 → 2015-08-24 A (-1d) |  | 0% → 100% | 0.25d → none | baseline start none → 2015-08-24; baseline finish none → 2015-08-25 |
| 7 | Aprobación de la directiva | 2015-08-25 → 2015-08-24 A (-1d) | 2015-08-25 → 2015-08-24 A (-1d) |  | 0% → 100% | 0.25d → none | baseline start none → 2015-08-25; baseline finish none → 2015-08-25 |
| 8 | Negociar nuevo alquiler | 2015-08-26 → 2015-08-25 A (-1d) | 2015-08-31 → 2015-08-27 A (-4d) | 4d → 3d | 0% → 100% | 0.25d → none | constraint finish no later than 2015-09-01 → none; baseline start none → 2015-08-26; baseline finish none → 2015-08-31 |
| 9 | Terminar dibujos | 2015-08-28 → 2015-08-26 A (-2d) | 2015-09-03 → 2015-09-01 A (-2d) |  | 0% → 100% | 0.25d → none | baseline start none → 2015-08-28; baseline finish none → 2015-09-03 |
| 10 | Seleccionar subcontratados | 2015-09-04 → 2015-09-02 A (-2d) | 2015-09-15 → 2015-09-11 A (-4d) |  | 0% → 100% | 0.25d → none | baseline start none → 2015-09-04; baseline finish none → 2015-09-15 |
| 11 | Contratar empresa de mudanzas | 2015-09-09 → 2015-09-07 A (-2d) | 2015-09-15 → 2015-09-11 A (-4d) |  | 0% → 100% | 0.25d → none | baseline start none → 2015-09-09; baseline finish none → 2015-09-15 |
| 12 | Enviar dibujos | 2015-09-15 → 2015-09-11 A (-4d) | 2015-09-24 → 2015-09-22 A (-2d) |  | 0% → 100% | 0.25d → none | baseline start none → 2015-09-15; baseline finish none → 2015-09-24 |
| 13 | Permisos recibidos | 2015-09-24 → 2015-09-22 A (-2d) | 2015-09-24 → 2015-09-22 A (-2d) |  | 0% → 100% | 0.25d → none | baseline start none → 2015-09-24; baseline finish none → 2015-09-24 |
| 14 | **Remodelación** | 2015-09-25 → 2015-09-23 A (-2d) | 2015-11-18 → 2015-11-16 (-2d) |  | 0% → 26% | 0.25d → 8.12d | baseline start none → 2015-09-25; baseline finish none → 2015-11-18 |
| 15 | Demolición del espacio existente | 2015-09-25 → 2015-09-23 A (-2d) | 2015-09-29 → 2015-09-25 A (-4d) |  | 0% → 100% | 0.25d → none | baseline start none → 2015-09-25; baseline finish none → 2015-09-29 |
| 16 | Levantar tabiques | 2015-09-30 → 2015-09-28 A (-2d) | 2015-10-05 → 2015-10-01 A (-4d) | 3.5d → 3.67d | 0% → 100% | 0.25d → none | baseline start none → 2015-09-30; baseline finish none → 2015-10-05 |
| 17 | Instalación eléctrica | 2015-10-05 → 2015-10-01 A (-4d) | 2015-10-13 → 2015-10-09 (-4d) |  | 0% → 89% | 0.25d → 0.08d | baseline start none → 2015-10-05; baseline finish none → 2015-10-13 |
| 18 | Instalación de líneas de voz y datos | 2015-10-14 → 2015-10-12 (-2d) | 2015-10-19 → 2015-10-15 (-4d) |  |  | 0.25d → 0.08d | baseline start none → 2015-10-14; baseline finish none → 2015-10-19 |
| 19 | Terminar paredes | 2015-10-19 → 2015-10-15 (-4d) | 2015-10-26 → 2015-10-22 (-4d) |  |  | 0.25d → 0.08d | baseline start none → 2015-10-19; baseline finish none → 2015-10-26 |
| 20 | Instalar puertas y ventanas | 2015-10-22 → 2015-10-20 (-2d) | 2015-10-27 → 2015-10-23 (-4d) |  |  | 0.25d → 0.08d | baseline start none → 2015-10-22; baseline finish none → 2015-10-27 |
| 21 | Pintar | 2015-10-27 → 2015-10-23 (-4d) | 2015-11-02 → 2015-10-29 (-4d) |  |  | 0.25d → 0.08d | baseline start none → 2015-10-27; baseline finish none → 2015-11-02 |
| 22 | Colocar moqueta: oficinas | 2015-11-02 → 2015-10-29 (-4d) | 2015-11-05 → 2015-11-03 (-2d) |  |  | 0.25d → 0.08d | baseline start none → 2015-11-02; baseline finish none → 2015-11-05 |
| 23 | Colocar linóleo: sala del servidor | 2015-11-02 → 2015-10-29 (-4d) | 2015-11-05 → 2015-11-03 (-2d) |  |  | 0.25d → 0.08d | baseline start none → 2015-11-02; baseline finish none → 2015-11-05 |
| 24 | Ultimas reparaciones | 2015-11-05 → 2015-11-03 (-2d) | 2015-11-12 → 2015-11-10 (-2d) |  |  | 0.25d → 0.08d | baseline start none → 2015-11-05; baseline finish none → 2015-11-12 |
| 25 | Probar sistemas | 2015-11-12 → 2015-11-10 (-2d) | 2015-11-16 → 2015-11-12 (-4d) |  |  | 1.25d → 1.08d | baseline start none → 2015-11-12; baseline finish none → 2015-11-16 |
| 26 | Revisión de acabado | 2015-11-12 → 2015-11-10 (-2d) | 2015-11-17 → 2015-11-13 (-4d) |  |  | 0.25d → 0.08d | baseline start none → 2015-11-12; baseline finish none → 2015-11-17 |
| 27 | Limpieza final | 2015-11-17 → 2015-11-13 (-4d) | 2015-11-18 → 2015-11-16 (-2d) |  |  |  | baseline start none → 2015-11-17; baseline finish none → 2015-11-18 |
| 28 | Remodelación terminada | 2015-11-18 → 2015-11-16 (-2d) | 2015-11-18 → 2015-11-16 (-2d) |  |  |  | baseline start none → 2015-11-18; baseline finish none → 2015-11-18 |
| 29 | **Traslado** | 2015-11-17 → 2015-11-13 (-4d) | 2015-12-01 → 2015-11-27 (-4d) |  |  |  | baseline start none → 2015-11-17; baseline finish none → 2015-12-01 |
| 30 | **Oficinas** | 2015-11-17 → 2015-11-13 (-4d) | 2015-11-25 → 2015-11-23 (-2d) |  |  |  | baseline start none → 2015-11-17; baseline finish none → 2015-11-25 |
| 31 | Desconectar computadoras/equipos | 2015-11-17 → 2015-11-13 (-4d) | 2015-11-19 → 2015-11-17 (-2d) |  |  |  | baseline start none → 2015-11-17; baseline finish none → 2015-11-19 |
| 32 | Desmontar mobiliario | 2015-11-18 → 2015-11-16 (-2d) | 2015-11-20 → 2015-11-18 (-2d) |  |  |  | baseline start none → 2015-11-18; baseline finish none → 2015-11-20 |
| 33 | Trasladar mobiliario/equipo/cajas | 2015-11-20 → 2015-11-18 (-2d) | 2015-11-23 → 2015-11-19 (-4d) |  |  |  | baseline start none → 2015-11-20; baseline finish none → 2015-11-23 |
| 34 | Montar mobiliario | 2015-11-23 → 2015-11-19 (-4d) | 2015-11-25 → 2015-11-23 (-2d) |  |  |  | baseline start none → 2015-11-23; baseline finish none → 2015-11-25 |
| 35 | Conectar computadoras/equipos | 2015-11-24 → 2015-11-20 (-4d) | 2015-11-25 → 2015-11-23 (-2d) |  |  |  | baseline start none → 2015-11-24; baseline finish none → 2015-11-25 |
| 36 | Oficinas terminadas | 2015-11-25 → 2015-11-23 (-2d) | 2015-11-25 → 2015-11-23 (-2d) |  |  |  | baseline start none → 2015-11-25; baseline finish none → 2015-11-25 |
| 37 | **Sala del servidor** | 2015-11-19 → 2015-11-17 (-2d) | 2015-12-01 → 2015-11-27 (-4d) |  |  |  | baseline start none → 2015-11-19; baseline finish none → 2015-12-01 |
| 38 | Hacer copia de seguridad del servidor | 2015-11-19 → 2015-11-17 (-2d) | 2015-11-23 → 2015-11-19 (-4d) |  |  |  | baseline start none → 2015-11-19; baseline finish none → 2015-11-23 |
| 39 | Desconectar servidor | 2015-11-23 → 2015-11-19 (-4d) | 2015-11-25 → 2015-11-23 (-2d) |  |  |  | baseline start none → 2015-11-23; baseline finish none → 2015-11-25 |
| 40 | Trasladar servidor | 2015-11-25 → 2015-11-23 (-2d) | 2015-11-26 → 2015-11-24 (-2d) |  |  |  | baseline start none → 2015-11-25; baseline finish none → 2015-11-26 |
| 41 | Conectar servidor | 2015-11-26 → 2015-11-24 (-2d) | 2015-11-30 → 2015-11-26 (-4d) |  |  |  | baseline start none → 2015-11-26; baseline finish none → 2015-11-30 |
| 42 | Probar servidor | 2015-11-30 → 2015-11-26 (-4d) | 2015-12-01 → 2015-11-27 (-4d) |  |  |  | baseline start none → 2015-11-30; baseline finish none → 2015-12-01 |
| 43 | Sala del servidor terminada | 2015-12-01 → 2015-11-27 (-4d) | 2015-12-01 → 2015-11-27 (-4d) |  |  |  | baseline start none → 2015-12-01; baseline finish none → 2015-12-01 |
| 44 | Traslado terminado | 2015-12-01 → 2015-11-27 (-4d) | 2015-12-01 → 2015-11-27 (-4d) |  |  |  | baseline start none → 2015-12-01; baseline finish none → 2015-12-01 |
